# Base project con festivos

Schedule from MS Project, 2024-07-02 to 2025-07-02, costs in $.
InKulpado666

## Calendars

- Estándar: Mon-Fri 07:00-12:00, 13:00-16:00; Sat 08:00-12:00; Sun off. Exceptions (off unless hours are given): 2024-07-20 (Grito de Independencia 2024), 2024-08-07 (Batalla de Boyacá 2024), 2024-08-19 (Asunción de la Virgen 2024), 2024-10-14 (Día de la Raza 2024), 2024-11-04 (Todos los Santos 2024), 2024-11-11 (Independencia de Cartagena 2024), 2024-12-08 (Inmaculada Concepcion 2024), 2024-12-25 (Navidad 2024), 2025-01-01 (Año Nuevo 2025), 2025-01-06 (Epifanía 2025), 2025-03-24 (San José 2025), 2025-04-17 to 2025-04-18 (Jueves y Viernes Santos 2025), 2025-05-01 (Día del Trabajo 2025), 2025-06-02 (Ascención del Señor 2025), 2025-06-23 (Corpus Christie 2025), 2025-06-30 (Sagrado Corazón 2025).

## Schedule

| ID | WBS | Task | Duration | Start | Finish | Predecessors | Total slack | Free slack | Cost |
| --- | --- | --- | --- | --- | --- | --- | --- | --- | --- |
| 1 | 1 | **PRELIMINARES** | 10d | 2024-07-02 | 2024-07-13 |  | 0d |  | 12,303,869 |
| 2 | 1.1 | LOCALIZACION-REPLANTEO ACUEDUCTO-ALCANTA | 3d | 2024-07-02 | 2024-07-04 |  | 0d |  | 8,315,525 |
| 3 | 1.2 | CAMPAMENTO TABLA 18 M2 | 3d | 2024-07-05 | 2024-07-09 | 2 | 0d |  | 3,007,111 |
| 4 | 1.3 | INSTALACION PROVISIONAL ACUEDUCTO | 10d | 2024-07-02 | 2024-07-13 |  | 262d |  | 981,233 |
| 5 | 2 | **DEMOLICION DE CAMARAS Y RETIRO DE TUBERIA** | 37d | 2024-07-18 | 2024-09-05 |  | 222d |  | 119,258,004 |
| 6 | 2.1 | EXCAVACION A MAQUINA SIN RETIRO | 7d | 2024-07-18 | 2024-07-26 | 16 | 222d | 0d | 4,055,658 |
| 7 | 2.2 | DEMOL.CAMARA DE CONCRETO | 13d | 2024-07-27 | 2024-08-14 | 6 | 239d |  | 5,449,438 |
| 8 | 2.3 | RETIRO TUBERIA EXISTENTE 0" A 12" | 21d | 2024-07-27 | 2024-08-26 | 6 | 222d | 0d | 9,930,434 |
| 9 | 2.4 | LIMPIEZA GENERAL | 2d | 2024-08-26 | 2024-08-28 | 8 | 229d |  | 182,626 |
| 10 | 2.5 | RETIRO DE ESCOMBROS A UNA ESCOMBRERA CERTIFICADA INCLUYE CARGUE A MANO Y ACARREO EN VOLQUETA | 9d | 2024-08-26 | 2024-09-05 | 8 | 222d |  | 99,639,848 |
| 11 | 3 | **DEMOLICIÓN POZOS SÉPTICOS EXISTENTES** | 23d? | 2024-07-09 | 2024-08-08 |  | 0d |  | 39,663,166 |
| 12 | 3.1 | LOCALIZACION-REPLANTEO OBRA ARQUITECTON. | 1d | 2024-07-09 | 2024-07-10 | 3 | 0d |  | 281,516 |
| 13 | 3.2 | DESCAPOTE MANUAL MAS RETIRO H= O.20 MTS | 2d | 2024-07-10 | 2024-07-12 | 12 | 0d |  | 228,805 |
| 14 | 3.3 | DEMOL.MURO CONCRETO E=30CM | 21d | 2024-07-10 | 2024-08-06 | 12 | 243d | 0d | 9,650,635 |
| 15 | 3.4 | DEMOL.LOSA CONCRETO E<=20CMS | 4d | 2024-07-10 | 2024-07-15 | 12 | 222d | 0d | 1,648,548 |
| 16 | 3.5 | RETIRO DE ESCOMBROS A UNA ESCOMBRERA CERTIFICADA INCLUYE CARGUE A MANO Y ACARREO EN VOLQUETA | 2d | 2024-07-16 | 2024-07-17 | 15 | 222d | 0d | 18,005,277 |
| 17 | 3.6 | RELLENO MATERIAL SITIO COMPACTADO-RANA | 3d | 2024-07-12 | 2024-07-16 | 13 | 0d |  | 2,897,905 |
| 18 | 3.7 | PROTECCION DE TALUDES (Entibado) | 1d? | 2024-08-08 | 2024-08-08 | 14 | 243d |  | 6,950,480 |
| 19 | 4 | **INSTALACIÓN DE TUBERIA DE ALCANTARILLADO** | 60d | 2024-07-17 | 2024-10-03 |  | 0d |  | 419,268,482 |
| 20 | 4.1 | EXCAVACION TIERRA A MANO | 30d | 2024-07-17 | 2024-08-27 | 17 | 230d |  | 30,675,471 |
| 21 | 4.2 | EXCAVACION EN CONGLOMERADO | 30d | 2024-07-17 | 2024-08-27 | 17 | 200d | 0d | 39,624,572 |
| 22 | 4.3 | RETIRO SOBRANTES TIERRA A MANO | 30d | 2024-08-27 | 2024-10-03 | 21 | 200d |  | 21,327,233 |
| 23 | 4.4 | RETIRO DE ESCOMBROS A UNA ESCOMBRERA CERTIFICADA INCLUYE CARGUE A MANO Y ACARREO EN VOLQUETA | 7d | 2024-08-27 | 2024-09-04 | 21 | 223d |  | 52,449,504 |
| 24 | 4.5 | PROTECCION DE TALUDES (Tablestaca) INCLUYE 3 REUSOS | 30d | 2024-07-17 | 2024-08-27 | 17 | 230d |  | 91,367,874 |
| 25 | 4.6 | RELLENO GRAVA TRITURA-POLVILLO [S.COM] | 17d | 2024-07-17 | 2024-08-08 | 17 | 243d |  | 36,537,301 |
| 26 | 4.7 | RELLENO ROCAMUERTA COMPACT-RANA | 4d | 2024-07-17 | 2024-07-22 | 17 | 0d |  | 57,201,454 |
| 27 | 4.8 | ACARREO MATERIALES PETREOS-TIERRA-VARIOS | 17d | 2024-07-17 | 2024-08-08 | 17 | 243d |  | 90,085,073 |

| ID | WBS | Task | Duration | Start | Finish | Predecessors | Total slack | Cost |
| --- | --- | --- | --- | --- | --- | --- | --- | --- |
| 28 | 5 | **CONSTRUCCION DE CAMARAS DE ALCANTARILLADO** | 22d | 2024-10-08 | 2024-11-07 |  | 0d | 86,983,871 |
| 29 | 5.1 | EXCAVACION EN CONGLOMERADO | 14d | 2024-10-08 | 2024-10-26 | 54 | 0d | 4,015,284 |
| 30 | 5.2 | RETIRO DE ESCOMBROS A UNA ESCOMBRERA CERTIFICADA INCLUYE CARGUE A MANO Y ACARREO EN VOLQUETA | 1d | 2024-10-28 | 2024-10-28 | 29 | 182d | 7,523,670 |
| 31 | 5.3 | SOLADO ESPESOR E=0.05M 3000 PSI 21 MPA | 2d | 2024-10-28 | 2024-10-29 | 29 | 0d | 2,378,832 |
| 32 | 5.4 | CAMARA INSPECCION TIPO B H=0.00-1.50 MTS | 2d | 2024-10-30 | 2024-10-31 | 31 | 0d | 3,864,982 |
| 33 | 5.5 | CAMARA INSPECCION TIPO B H=1.50-2.00 MTS | 4d | 2024-10-30 | 2024-11-05 | 31 | 177d | 16,903,854 |
| 34 | 5.6 | CAMARA INSPECCION TIPO B H=2.01-2.50 MTS | 4d | 2024-10-30 | 2024-11-05 | 31 | 177d | 11,661,383 |
| 35 | 5.7 | CAMARA INSPECCION TIPO B H=2.51-3.00 MTS | 6d | 2024-10-30 | 2024-11-07 | 31 | 175d | 20,767,609 |
| 36 | 5.8 | CAMARA INSPECCION TIPO B H=3.01-3.50 MTS | 6d | 2024-10-30 | 2024-11-07 | 31 | 175d | 16,841,619 |
| 37 | 5.9 | CAMARA INSPECCION TIPO B H=3.51-4.00 MTS | 6d | 2024-10-30 | 2024-11-07 | 31 | 175d | 3,026,638 |
| 38 | 6 | **RETIRO DE ACOMETIDAS DE ALCANTARILLADO** | 40d | 2024-07-23 | 2024-09-13 |  | 0d | 120,145,169 |
| 39 | 6.1 | EXCAVACION TIERRA A MANO | 10d | 2024-07-23 | 2024-08-03 | 26 | 0d | 22,922,916 |
| 40 | 6.2 | RETIRO TUBERIA EXISTENTE 0" A 12" | 7d | 2024-08-05 | 2024-08-14 | 39 | 0d | 8,914,467 |
| 41 | 6.3 | DEMOL.CAJA INSPECCION | 14d | 2024-07-23 | 2024-08-09 | 26 | 242d | 3,820,486 |
| 42 | 6.4 | RETIRO SOBRANTES TIERRA A MANO | 30d | 2024-08-05 | 2024-09-13 | 39 | 216d | 9,169,166 |
| 43 | 6.5 | RETIRO DE ESCOMBROS A UNA ESCOMBRERA CERTIFICADA INCLUYE CARGUE A MANO Y ACARREO EN VOLQUETA | 7d | 2024-08-14 | 2024-08-23 | 40 | 232d | 75,165,317 |
| 44 | 6.6 | LIMPIEZA GENERAL | 2d | 2024-08-14 | 2024-08-16 | 40 | 237d | 152,817 |
| 45 | 7 | **INSTALACION DE NUEVAS ACOMETIDAS DE ALCANTARILLADO** | 52d | 2024-08-14 | 2024-10-22 |  | 0d | 270,347,436 |
| 46 | 7.1 | EXCAVACION TIERRA A MANO | 7d | 2024-08-14 | 2024-08-23 | 40 | 0d | 2,304,420 |
| 47 | 7.2 | CONFIGURACION-NIVELACION TERRENO | 2d | 2024-08-24 | 2024-08-27 | 46 | 0d | 646,663 |
| 48 | 7.3 | RELLENO GRAVA TRITURA-POLVILLO [S.COM] | 6d | 2024-09-05 | 2024-09-12 | 50 | 0d | 23,438,099 |
| 49 | 7.4 | RELLENO ROCAMUERTA COMPACT-RANA | 6d | 2024-08-27 | 2024-09-03 | 47 | 0d | 24,575,903 |
| 50 | 7.5 | SUB-BASE COMP.MAT.SELECC. TIPO INV SIN T | 1d | 2024-09-04 | 2024-09-04 | 49 | 0d | 14,105,709 |
| 51 | 7.6 | ACARREO MATERIALES PETREOS-TIERRA-VARIOS | 12d | 2024-08-14 | 2024-08-30 | 40 | 227d | 293,899 |
| 52 | 7.7 | ANDEN CONCRETO 10CM 3000 PSI (INCLUYE MALLA ELECTROSOLDADA GRAFIL 6.0MM 15X15) | 30d | 2024-09-12 | 2024-10-22 | 48 | 187d | 58,838,555 |
| 53 | 7.8 | CAJA INSPECCION 70X70, EXCAV H= 1.0M | 13d | 2024-09-12 | 2024-09-28 | 48 | 0d | 107,452,372 |
| 54 | 7.9 | TAPA CAJA MARCO ANGULO 61X61 - 70X70 | 7d | 2024-09-30 | 2024-10-08 | 53 | 0d | 37,930,407 |
| 55 | 7.10 | RETIRO DE ESCOMBROS A UNA ESCOMBRERA CERTIFICADA INCLUYE CARGUE A MANO Y ACARREO EN VOLQUETA | 15d | 2024-08-24 | 2024-09-12 | 46 | 217d | 761,409 |

| ID | WBS | Task | Duration | Start | Finish | Predecessors | Total slack | Free slack | Cost |
| --- | --- | --- | --- | --- | --- | --- | --- | --- | --- |
| 56 | 8 | **REPOSICION DE PAVIMENTO RIGIDO** | 34d | 2024-11-19 | 2025-01-03 |  | 0d |  | 484,147,065 |
| 57 | 8.1 | LOCALIZACION-REPLANTEO VIAS URBANAS | 4d | 2024-11-19 | 2024-11-23 | 74 | 0d |  | 3,067,722 |
| 58 | 8.2 | DEMOL.PAVIMENTO CONCRETO E=20CM | 21d | 2024-11-25 | 2024-12-20 | 57 | 133d | 0d | 43,264,114 |
| 59 | 8.3 | RETIRO DE ESCOMBROS A UNA ESCOMBRERA CERTIFICADA INCLUYE CARGUE A MANO Y ACARREO EN VOLQUETA | 9d | 2024-12-20 | 2025-01-03 | 58 | 133d |  | 45,090,624 |
| 60 | 8.4 | CONFORM.COMPACT.SUBRASANTE CBR=95 | 3d | 2024-11-25 | 2024-11-27 | 57 | 0d |  | 8,280,807 |
| 61 | 8.5 | BASE COMP.MAT. TRITURAD GRANUL SIN TRAN | 2d | 2024-11-28 | 2024-11-29 | 60 | 0d |  | 48,792,571 |
| 62 | 8.6 | PAV.CONCR.PREM MR=38.E=0.20,INC. JUNTA -BAKE | 14d | 2024-11-30 | 2024-12-18 | 61 | 0d |  | 335,651,227 |
| 63 | 9 | **DEMOLICION DE ESTRUCTURA EXISTENTE POZO DE BOMBEO** | 23d? | 2024-11-01 | 2024-12-03 |  | 0d |  | 33,399,212 |
| 64 | 9.1 | LOCALIZACION-REPLANTEO OBRA ARQUITECTON. | 1d | 2024-11-01 | 2024-11-01 | 32 | 0d |  | 114,324 |
| 65 | 9.2 | DESCAPOTE MANUAL MAS RETIRO H= O.20 MTS | 1d | 2024-11-02 | 2024-11-05 | 64 | 177d |  | 92,918 |
| 66 | 9.3 | DEMOL.MURO CONCRETO E=30CM | 14d | 2024-11-14 | 2024-12-02 | 67 | 156d | 0d | 6,891,610 |
| 67 | 9.4 | DEMOL.LOSA MACIZA C. E>=20CMS | 7d | 2024-11-02 | 2024-11-13 | 64 | 0d |  | 2,639,104 |
| 68 | 9.5 | DEMOL.COLUMNA CONCRETO AMARRE | 2d | 2024-11-14 | 2024-11-15 | 67 | 169d |  | 135,840 |
| 69 | 9.6 | DEMOL.VIGA AMARRE MURO | 2d | 2024-11-02 | 2024-11-06 | 64 | 176d |  | 199,070 |
| 70 | 9.7 | DEMOL.CIMIENTO CONCRETO (CR) | 2d | 2024-11-02 | 2024-11-06 | 64 | 176d |  | 506,900 |
| 71 | 9.8 | DEMOL.MURO LAD. SOGA | 2d | 2024-11-14 | 2024-11-15 | 67 | 0d |  | 187,669 |
| 72 | 9.9 | DESM.MALLA ESLABONADA H=2.0 MT | 2d | 2024-11-14 | 2024-11-15 | 67 | 169d |  | 169,126 |
| 73 | 9.10 | DESM.MARCO + NAVE SENCILLA | 1d | 2024-11-16 | 2024-11-18 | 71 | 0d |  | 53,905 |
| 74 | 9.11 | RETIRO DE ESCOMBROS A UNA ESCOMBRERA CERTIFICADA INCLUYE CARGUE A MANO Y ACARREO EN VOLQUETA | 1d | 2024-11-18 | 2024-11-19 | 73 | 0d |  | 4,597,685 |
| 75 | 9.12 | PROTECCION DE TALUDES (Entibado) | 1d? | 2024-12-02 | 2024-12-03 | 66, 67 | 156d |  | 17,376,200 |
| 76 | 9.13 | EXCAVACION A MAQUINA SIN RETIRO | 1d? | 2024-12-02 | 2024-12-03 | 66 | 156d |  | 434,861 |
| 77 | 10 | **CUBIERTA DE POZO DE BOMBEO** | 25d | 2025-02-21 | 2025-03-26 |  | 0d |  | 49,796,289 |
| 78 | 10.1 | EXCAVACION TIERRA A MANO | 6d | 2025-02-21 | 2025-02-28 | 173 | 0d |  | 567,615 |
| 79 | 10.2 | ZAPATA CONCRETO 3000 PSI 21 MPA | 1d | 2025-03-03 | 2025-03-03 | 80 | 71d | 0d | 1,619,145 |
| 80 | 10.3 | SOLADO ESPESOR E=0.05M 3000 PSI 21 MPA | 1d | 2025-02-28 | 2025-03-01 | 78 | 71d | 0d | 547,475 |
| 81 | 10.4 | VIGA CIMIENTO ENLACE H=20-40CM 3100PSI | 3d | 2025-03-04 | 2025-03-06 | 79 | 71d | 0d | 2,678,095 |
| 82 | 10.5 | COLUMNA CONCRETO 3000 PSI | 4d | 2025-03-07 | 2025-03-12 | 81 | 81d |  | 4,625,473 |
| 83 | 10.6 | VIGA CONCRETO AEREA 3000 PSI | 5d | 2025-03-14 | 2025-03-20 | 87 | 71d | 0d | 3,949,493 |
| 84 | 10.7 | CONTRAPISO CONCRETO E= 8CM 2.500Psi | 2d | 2025-03-07 | 2025-03-10 | 81 | 71d | 0d | 1,381,050 |
| 85 | 10.8 | TUBO ESTRUCTURAL 60X60X2.0MM | 1d | 2025-03-21 | 2025-03-21 | 83 | 73d |  | 3,302,389 |
| 86 | 10.9 | PERFIL ABIERTO HR C120x 60mm -1.5MM C.16 | 1d | 2025-03-21 | 2025-03-21 | 83 | 73d |  | 312,052 |
| 87 | 10.10 | MURO BLOQUE ESTRUCT.CERAMICO 10X12X29 | 4d | 2025-03-10 | 2025-03-14 | 84 | 71d | 0d | 6,463,860 |
| 88 | 10.11 | ACERO REFUERZO FLEJADO 60000 PSI 420Mpa | 7d | 2025-02-28 | 2025-03-10 | 78 | 0d |  | 18,190,125 |
| 89 | 10.12 | MEZCLA GROUTING 1:2:3 3100 PSI -22,0 MPA | 1d | 2025-03-14 | 2025-03-15 | 87 | 78d |  | 381,796 |
| 90 | 10.13 | PERFIL IPE-240 | 1d | 2025-03-25 | 2025-03-26 | 95 | 71d |  | 2,516,397 |
| 91 | 10.14 | PLACA ASTM A572 GR50 300X300X12MM | 1d | 2025-03-21 | 2025-03-21 | 83 | 73d |  | 627,820 |
| 92 | 10.15 | PLACA ASTM A572 GR50 160X160X12MM | 1d | 2025-03-21 | 2025-03-21 | 83 | 73d |  | 428,070 |
| 93 | 10.16 | PLACA ASTM A572 GR50 160X85X12MM | 1d | 2025-03-21 | 2025-03-21 | 83 | 71d | 0d | 390,876 |
| 94 | 10.17 | ANCLAJE HIERRO ,1/2"-PERF. 5/8" 23C | 1d | 2025-03-22 | 2025-03-25 | 93 | 72d |  | 354,400 |
| 95 | 10.18 | ANCLAJE HIERRO ,1/2"-PERF. 5/8" 28C | 1d | 2025-03-22 | 2025-03-25 | 93 | 71d | 0d | 538,456 |
| 96 | 10.19 | CANAL AMAZONAS PVC AGUAS LLUVIAS | 1d | 2025-03-11 | 2025-03-12 | 98 | 0d |  | 492,790 |
| 97 | 10.20 | TAPA EXTERNA CANAL AMAZONAS PVC | 1d | 2025-03-12 | 2025-03-13 | 96 | 80d |  | 16,691 |
| 98 | 10.21 | SOPORTE CANAL AMAZONAS PVC | 1d | 2025-03-10 | 2025-03-11 | 88 | 0d |  | 95,334 |
| 99 | 10.22 | UNION ESQUINA CANAL AMAZONAS PVC | 1d | 2025-03-12 | 2025-03-13 | 96 | 80d |  | 35,777 |
| 100 | 10.23 | UNION CANAL AMAZONAS PVC | 1d | 2025-03-12 | 2025-03-13 | 96 | 0d |  | 64,115 |
| 101 | 10.24 | BAJANTE AGUAS LLUVIAS PVC CUADRADO CANAL | 1d | 2025-03-13 | 2025-03-14 | 100 | 79d |  | 180,097 |
| 102 | 10.25 | CODO BAJANTE 45 CANAL PVC | 1d | 2025-03-13 | 2025-03-14 | 100 | 79d |  | 23,843 |
| 103 | 10.26 | CODO BAJANTE 90 CANAL PVC | 1d | 2025-03-13 | 2025-03-14 | 100 | 0d |  | 13,055 |

| ID | WBS | Task | Duration | Start | Finish | Predecessors | Total slack | Free slack | Cost |
| --- | --- | --- | --- | --- | --- | --- | --- | --- | --- |
| 104 | 11 | **MONTAJE MECANICO DE ESTACIÓN DE BOMBEO** | 4d | 2025-03-14 | 2025-03-19 |  | 75d |  | 96,987,442 |
| 105 | 11.1 | BOMBA SUMERGIBLE 10 HP PARA AGUAS RESIDUALES (INCLUYE SISTEMA DE ELEVACIÓN CON AUTOCOPLAMIENTO) | 2d | 2025-03-14 | 2025-03-17 | 103 | 75d | 0d | 41,272,741 |
| 106 | 11.2 | TABLERO ELECTRICO DE CONTROL CON VARIADOR DE VELOCIDAD | 2d | 2025-03-18 | 2025-03-19 | 105 | 75d |  | 15,124,516 |
| 107 | 11.3 | CESTA DE CRIBADO CON IZAJE (INCLUYE RIELES) | 2d | 2025-03-14 | 2025-03-17 | 103 | 77d |  | 40,590,185 |
| 108 | 12 | **OBRAS DE POZO HÚMEDO Y CÁMARA DE CRIBADO** | 31d | 2024-12-18 | 2025-01-30 |  | 0d |  | 145,468,819 |
| 109 | 12.1 | LOCALIZACION-REPLANTEO OBRA ARQUITECTON. | 1d | 2024-12-18 | 2024-12-19 | 62 | 0d |  | 318,599 |
| 110 | 12.2 | EXCAVACION MANUAL.TIERRA SECA H=1.8M(SR) | 7d | 2024-12-19 | 2024-12-30 | 109 | 0d |  | 6,636,568 |
| 111 | 12.3 | PROTECCION DE TALUDES (Tablestaca) | 10d | 2024-12-30 | 2025-01-14 | 110 | 0d |  | 10,356,218 |
| 112 | 12.4 | RELLENO COMP.MAT.SELECC.SIN TRANSP (ROCA | 1d | 2025-01-14 | 2025-01-15 | 111 | 0d |  | 4,331,636 |
| 113 | 12.5 | SOLADO ESPESOR E=0.05M 3000 PSI 21 MPA | 1d | 2025-01-15 | 2025-01-16 | 112 | 0d |  | 863,549 |
| 114 | 12.6 | LOSA FONDO TANQUE ENTERRADO 4500PSI-31MPA | 1d | 2025-01-16 | 2025-01-17 | 113, 116 | 0d |  | 8,364,540 |
| 115 | 12.7 | MURO CONCRETO TANQUE SUBTERRANEO 31 MPA (4500PSI) | 10d | 2025-01-17 | 2025-01-30 | 114, 116 | 0d |  | 53,071,208 |
| 116 | 12.8 | ACERO REFUERZO FLEJADO 60000 PSI 420Mpa | 14d | 2024-12-19 | 2025-01-09 | 109 | 5d |  | 52,169,890 |
| 117 | 12.9 | IMPERMEABILIZANTE CONCRETO FUNDIDO | 5d | 2024-12-19 | 2024-12-26 | 109 | 138d |  | 5,839,358 |
| 118 | 12.10 | PLASTIFICANTE IMPERMEABILIZANTE. | 21d | 2024-12-19 | 2025-01-18 | 109 | 122d |  | 3,517,253 |
| 119 | 13 | **CUARTO ELÉCTRICO BODEGA Y BAÑO** | 24d | 2025-01-30 | 2025-03-01 |  | 0d |  | 33,458,784 |
| 120 | 13.1 | LOCALIZACION-REPLANTEO OBRA ARQUITECTON. | 1d | 2025-01-30 | 2025-01-31 | 115 | 0d |  | 98,945 |
| 121 | 13.2 | EXCAVACION A MAQUINA SIN RETIRO | 1d | 2025-01-31 | 2025-02-01 | 120 | 3d | 0d | 20,360 |
| 122 | 13.3 | ACERO REFUERZO FLEJADO 60000 PSI 420Mpa | 5d | 2025-01-31 | 2025-02-06 | 120 | 0d |  | 5,909,502 |
| 123 | 13.4 | VIGA CIMIENTO ENLACE H=20-40CM 3100PSI | 2d | 2025-02-07 | 2025-02-10 | 122, 132 | 0d |  | 2,020,761 |
| 124 | 13.5 | VIGA CONCRETO AEREA 3000 PSI | 2d | 2025-02-18 | 2025-02-19 | 126 | 89d | 0d | 1,197,894 |
| 125 | 13.6 | CONTRAPISO CONCRETO E= 8CM 2.500Psi | 2d | 2025-02-10 | 2025-02-12 | 123 | 0d |  | 976,810 |
| 126 | 13.7 | MURO BLOQUE ESTRUCT.CERAMICO 10X12X29 | 4d | 2025-02-12 | 2025-02-17 | 125 | 0d |  | 5,525,180 |
| 127 | 13.8 | TUBO ESTRUCTURAL 50X50X1.5MM | 1d | 2025-02-20 | 2025-02-20 | 124 | 89d | 0d | 3,031,242 |
| 128 | 13.9 | TEJA AJOVER N10 TERMOACUSTICA | 1d | 2025-02-21 | 2025-02-21 | 127 | 89d | 0d | 1,983,221 |
| 129 | 13.10 | TABLETA GRESS 20X20 | 2d | 2025-02-12 | 2025-02-14 | 125 | 101d |  | 865,554 |
| 130 | 13.11 | MESON EN CONCRETO A <=60 CM H=5.0- 8CM | 1d | 2025-02-18 | 2025-02-18 | 126 | 0d |  | 150,249 |
| 131 | 13.12 | ENCHAPE CERAMICA 25x25 41.0-60.0 MESON | 1d | 2025-02-19 | 2025-02-19 | 130 | 0d |  | 58,629 |
| 132 | 13.13 | CONCRETO CICLOPEO 3000 PSI RELAC 60C/40P | 1d | 2025-02-03 | 2025-02-03 | 121 | 3d |  | 894,993 |
| 133 | 13.14 | MEZCLA GROUTING 1:2:3 3100 PSI -22,0 MPA | 1d | 2025-02-18 | 2025-02-18 | 126 | 98d |  | 567,088 |
| 134 | 13.15 | PLACA ASTM A572 GR50 120X200X12MM | 1d | 2025-02-20 | 2025-02-20 | 124 | 95d | 0d | 424,626 |
| 135 | 13.16 | ANCLAJE HIERRO ,1/2"-PERF. 5/8" 35C | 1d | 2025-02-21 | 2025-02-21 | 134 | 95d |  | 182,694 |
| 136 | 13.17 | MARCO LAM. 0.70-1.0 M CAL.20 PEST S/LUCE | 1d | 2025-02-18 | 2025-02-18 | 126 | 93d | 0d | 253,728 |
| 137 | 13.18 | NAVE LAM.LLENA BAT.+CERR.+PINT CAL.20 | 4d | 2025-02-20 | 2025-02-25 | 138 | 93d |  | 1,797,504 |
| 138 | 13.19 | MARCO LAM. 1.51-2.0 M CAL.20 PEST S/LUCE | 1d | 2025-02-19 | 2025-02-19 | 136 | 93d | 0d | 215,796 |
| 139 | 13.20 | LUCETA ALUM CORREDIZA 5020 H 50CM [OX] | 2d | 2025-02-18 | 2025-02-19 | 126 | 97d |  | 1,166,652 |
| 140 | 13.21 | CANAL AMAZONAS PVC AGUAS LLUVIAS | 1d | 2025-02-22 | 2025-02-24 | 128 | 89d | 0d | 387,588 |
| 141 | 13.22 | UNION CANAL AMAZONAS PVC | 1d | 2025-02-24 | 2025-02-25 | 140 | 93d |  | 64,115 |
| 142 | 13.23 | TAPA EXTERNA CANAL AMAZONAS PVC | 1d | 2025-02-24 | 2025-02-25 | 140 | 93d |  | 16,691 |
| 143 | 13.24 | SOPORTE CANAL AMAZONAS PVC | 1d | 2025-02-24 | 2025-02-25 | 140 | 93d |  | 71,500 |
| 144 | 13.25 | UNION ESQUINA CANAL AMAZONAS PVC | 1d | 2025-02-24 | 2025-02-25 | 140 | 93d |  | 35,777 |
| 145 | 13.26 | BAJANTE AGUAS LLUVIAS PVC CUADRADO CANAL | 1d | 2025-02-24 | 2025-02-25 | 140 | 89d | 0d | 158,910 |
| 146 | 13.27 | CODO BAJANTE 45 CANAL PVC | 1d | 2025-02-25 | 2025-02-26 | 145 | 92d |  | 47,687 |
| 147 | 13.28 | CODO BAJANTE 90 CANAL PVC | 1d | 2025-02-25 | 2025-02-26 | 145 | 92d |  | 13,055 |
| 148 | 13.29 | TUBERIA PVC 2 SANITARIA (LOSA ) | 1d | 2025-02-25 | 2025-02-26 | 145 | 90d | 0d | 58,798 |
| 149 | 13.30 | TUBERIA PVC 4 SANITARIA (LOSA) | 1d | 2025-02-25 | 2025-02-26 | 145 | 89d | 0d | 278,987 |
| 150 | 13.31 | YEE SANITARIA SENCILLA 2 PVC | 1d | 2025-02-26 | 2025-02-27 | 148 | 91d |  | 20,180 |
| 151 | 13.32 | YEE SANITARIA SENCILLA 4 PVC | 1d | 2025-02-26 | 2025-02-27 | 149 | 91d |  | 86,344 |
| 152 | 13.33 | REDUCCION SANITARIA PVC 4X2 | 1d | 2025-02-26 | 2025-02-27 | 149 | 91d |  | 10,747 |
| 153 | 13.34 | CODO SANITARIO PVC 45 CC-2" | 1d | 2025-02-26 | 2025-02-27 | 149 | 91d |  | 11,774 |
| 154 | 13.35 | CODO SANITARIO PVC 45 CC-4" | 1d | 2025-02-26 | 2025-02-27 | 149 | 91d |  | 40,255 |
| 155 | 13.36 | CODO SANITARIO PVC 90 CC-2 | 1d | 2025-02-26 | 2025-02-27 | 148 | 90d | 0d | 4,633 |
| 156 | 13.37 | CODO SANITARIO PVC 90 CC-4" | 1d | 2025-02-26 | 2025-02-27 | 149 | 91d |  | 31,279 |
| 157 | 13.38 | TEE SANITARIA PVC 4" SENCILLA | 1d | 2025-02-26 | 2025-02-27 | 149 | 91d |  | 23,620 |
| 158 | 13.39 | REJILLA SOSCO 3"X2" ALUMINIO" | 1d | 2025-02-27 | 2025-02-28 | 155 | 90d |  | 38,828 |
| 159 | 13.40 | SIFON SANITARIO PVC 2" | 1d | 2025-02-27 | 2025-02-28 | 155 | 90d |  | 16,355 |
| 160 | 13.41 | PUNTO AGUA FRIA PVC ,1/2 | 1d | 2025-02-05 | 2025-02-05 | 174 | 108d |  | 165,032 |
| 161 | 13.42 | PUNTO SANITARIO PVC 2 | 1d | 2025-02-26 | 2025-02-27 | 148 | 91d |  | 117,841 |
| 162 | 13.43 | PUNTO SANITARIO PVC 4 [L] | 1d | 2025-02-26 | 2025-02-27 | 149 | 89d | 0d | 97,588 |
| 163 | 13.44 | TUBERIA PVC ,1/2" | 1d | 2025-02-03 | 2025-02-03 | 121 | 107d | 0d | 78,909 |
| 164 | 13.45 | TEE PRESION PVC ,1/2" | 1d | 2025-02-04 | 2025-02-04 | 163 | 109d |  | 3,161 |
| 165 | 13.46 | CODO 90 PRESION PVC ,1/2" | 1d | 2025-02-04 | 2025-02-04 | 163 | 109d |  | 1,065 |
| 166 | 13.47 | COMBO SANITARIO LINEA MEDIA [S+L+G+I | 1d | 2025-02-20 | 2025-02-20 | 131 | 96d |  | 626,711 |
| 167 | 13.48 | MEDIDOR DE AGUA VOLUMETRICO JSM 1/2" | 1d | 2025-02-04 | 2025-02-04 | 163 | 107d | 0d | 121,222 |
| 168 | 13.49 | INSTALACION MEDIDOR AGUA | 1d | 2025-02-05 | 2025-02-05 | 167 | 107d | 0d | 34,666 |
| 169 | 13.50 | GABINETE CONTRA INCENDIO CLASE II | 1d | 2025-02-06 | 2025-02-06 | 168 | 107d |  | 1,877,249 |
| 170 | 13.51 | TUBERIA PVC 4 VENTILACION | 1d | 2025-02-27 | 2025-02-28 | 162 | 90d |  | 97,241 |
| 171 | 13.52 | CAJA INSPECCION 60x 60 CM [CONCRETO] | 1d | 2025-02-27 | 2025-02-28 | 162 | 89d | 0d | 835,117 |
| 172 | 13.53 | TAPA CAJA MARCO ANGULO 61X61 - 70X70 | 1d | 2025-02-28 | 2025-03-01 | 171 | 89d |  | 364,715 |
| 173 | 13.54 | LAVADERO PR.GRANITO PULIDO 100X 60CM | 1d | 2025-02-20 | 2025-02-20 | 131 | 0d |  | 180,004 |

| ID | WBS | Task | Duration | Start | Finish | Predecessors | Total slack | Free slack | Cost |
| --- | --- | --- | --- | --- | --- | --- | --- | --- | --- |
| 174 | 13.55 | VALVULA CIERRE METALICO ,1/2" | 1d | 2025-02-04 | 2025-02-04 | 163 | 108d | 0d | 99,712 |
| 175 | 14 | **CERRAMIENTO DE ESTACIÓN DE BOMBEO** | 19d | 2025-03-14 | 2025-04-09 |  | 0d |  | 23,903,418 |
| 176 | 14.1 | DESCAPOTE MANUAL MAS RETIRO H= O.20 MTS | 4d | 2025-03-14 | 2025-03-19 | 103 | 0d |  | 53,534 |
| 177 | 14.2 | EXCAVACION MANUAL.TIERRA SECA H=1.8M(SR) | 2d | 2025-03-20 | 2025-03-21 | 176 | 2d | 0d | 308,065 |
| 178 | 14.3 | RELLENO MATERIAL SITIO COMPACTADO-RANA | 1d | 2025-03-22 | 2025-03-25 | 177 | 63d | 0d | 110,380 |
| 179 | 14.4 | RETIRO SOBRANTES TIERRA A MANO | 2d | 2025-03-22 | 2025-03-26 | 177 | 71d |  | 160,204 |
| 180 | 14.5 | MEZCLA GROUTING 1:2:3 3100 PSI -22,0 MPA | 1d | 2025-03-14 | 2025-03-15 | 103 | 78d |  | 262,785 |
| 181 | 14.6 | VIGA CIMIENTO H=0.60M CONCRETO 21 MPA (3000PSI) | 4d | 2025-03-26 | 2025-03-31 | 177, 183 | 0d |  | 5,921,583 |
| 182 | 14.7 | COLUMNA CONCRETO 3000 PSI | 1d | 2025-04-05 | 2025-04-07 | 184, 183 | 0d |  | 713,644 |
| 183 | 14.8 | ACERO REFUERZO FLEJADO 60000 PSI 420Mpa | 4d | 2025-03-20 | 2025-03-26 | 176 | 0d |  | 5,014,551 |
| 184 | 14.9 | MURO BLOQUE CONCRETO 14x19x39CM | 4d | 2025-04-01 | 2025-04-04 | 181 | 0d |  | 1,704,959 |
| 185 | 14.10 | POSTE TUBO GALV. 1,1/2"x1.5MM C.16" | 1d | 2025-04-07 | 2025-04-08 | 182 | 0d |  | 1,541,786 |
| 186 | 14.11 | MALLA ESLABONADA GALV # 10 ROMBO 1,1/2" (INCLUYE ALAMBRE DE PUAS # 12.5 3 HILOS, VARILLA TENSOR MALLA) | 1d | 2025-04-08 | 2025-04-09 | 185 | 0d |  | 1,454,391 |
| 187 | 14.12 | ANDEN CONCRETO 10CM 3000 PSI | 9d | 2025-03-25 | 2025-04-04 | 178 | 63d |  | 6,657,536 |
| 188 | 15 | **VIA DE ACCESO EBAR** | 4d | 2025-04-09 | 2025-04-14 |  | 0d |  | 7,263,897 |
| 189 | 15.1 | EXCAVACION A MAQUINA(CAJEO) [SR] | 1d | 2025-04-09 | 2025-04-10 | 186 | 0d |  | 155,747 |
| 190 | 15.2 | CONFORM.COMPACT.SUBRASANTE CBR=95 | 1d | 2025-04-10 | 2025-04-11 | 189 | 0d |  | 121,793 |
| 191 | 15.3 | SUB-BASE COMP.MAT.SELECC. TIPO INV SIN T | 1d | 2025-04-11 | 2025-04-12 | 190 | 0d |  | 1,181,353 |
| 192 | 15.4 | PAV.CONCR.MR=36 E=0.20,INC.JUNTA- BAKE | 1d | 2025-04-14 | 2025-04-14 | 191, 194 | 56d |  | 4,405,262 |
| 193 | 15.5 | SARDINEL TRAPEZOIDAL B(10-15) H=26-35CM | 1d | 2025-04-14 | 2025-04-14 | 191, 194 | 0d |  | 509,137 |
| 194 | 15.6 | ACERO REFUERZO FLEJADO 60000 PSI 420Mpa | 1d | 2025-04-09 | 2025-04-10 | 186 | 2d |  | 890,605 |
| 195 | 16 | **CONSTRUCCIÓN DE LÍNEA DE IMPULSIÓN** | 33d | 2025-04-15 | 2025-05-29 |  | 0d |  | 118,618,765 |
| 196 | 16.1 | RETIRO TUBERIA EXISTENTE 0" A 12" | 30d | 2025-04-21 | 2025-05-29 | 199 | 23d |  | 17,083,704 |
| 197 | 16.2 | RETIRO DE ESCOMBROS A UNA ESCOMBRERA CERTIFICADA INCLUYE CARGUE A MANO Y ACARREO EN VOLQUETA | 6d | 2025-04-21 | 2025-04-28 | 199 | 47d |  | 38,478,333 |
| 198 | 16.3 | EXCAVACION TIERRA A MANO | 30d | 2025-04-15 | 2025-05-26 | 193 | 26d |  | 14,667,432 |
| 199 | 16.4 | EXCAVACION A MAQUINA SIN RETIRO | 3d | 2025-04-15 | 2025-04-21 | 193 | 0d |  | 1,957,628 |
| 200 | 16.5 | CONFIGURACION-NIVELACION TERRENO | 4d | 2025-04-21 | 2025-04-25 | 199 | 49d |  | 1,127,929 |
| 201 | 16.6 | COLCHON ARENA GRUESA E=5-7CM | 6d | 2025-04-21 | 2025-04-28 | 199 | 0d |  | 10,591,610 |
| 202 | 16.7 | RELLENO MATERIAL SITIO COMPACTADO RANA | 30d | 2025-04-21 | 2025-05-29 | 199 | 23d |  | 22,693,971 |
| 203 | 16.8 | RELLENO ROCAMUERTA COMPACT-RANA | 10d | 2025-04-29 | 2025-05-12 | 201 | 0d |  | 12,018,158 |

| ID | WBS | Task | Duration | Start | Finish | Predecessors | Total slack | Free slack | Cost |
| --- | --- | --- | --- | --- | --- | --- | --- | --- | --- |
| 204 | 17 | **VIADUCTOS No. 1 Y 3** | 23d | 2025-05-29 | 2025-07-01 |  | 1d |  | 58,809,195 |
| 205 | 17.1 | LOCALIZACION-REPLANTEO OBRA ARQUITECTON. | 1d | 2025-05-29 | 2025-05-29 | 240 | 1d | 0d | 1,296,680 |
| 206 | 17.2 | EXCAVACION EN CONGLOMERADO | 3d | 2025-05-30 | 2025-06-04 | 205 | 3d | 0d | 1,510,342 |
| 207 | 17.3 | SOLADO DE LIMPIEZA E:5CM 17,5 MPA (2500 PSI) | 2d | 2025-06-04 | 2025-06-06 | 206 | 3d | 2d | 221,920 |
| 208 | 17.4 | ACERO REFUERZO FLEJADO 60000 PSI 420Mpa | 7d | 2025-05-30 | 2025-06-09 | 205 | 1d | 0d | 4,965,329 |
| 209 | 17.5 | ZAPATA CONCRETO 3000 PSI INC. FORMALETA E:0.35M | 2d | 2025-06-10 | 2025-06-11 | 207, 208 | 1d | 0d | 1,881,360 |
| 210 | 17.6 | PEDESTAL EN CONCRETO 21 MPA (3000 PSI) 0,35X0,65 | 4d | 2025-06-12 | 2025-06-17 | 209 | 1d | 0d | 2,444,651 |
| 211 | 17.7 | MEZCLA GROUTING 1:2:3 3100 PSI -22,0 MPA | 2d | 2025-06-12 | 2025-06-13 | 209 | 12d |  | 26,029 |
| 212 | 17.8 | GROUTING DE NIVELACIÓN E:5 CM 12,5 MPA (1785 PSI) | 2d | 2025-06-12 | 2025-06-13 | 209 | 12d |  | 260,007 |
| 213 | 17.9 | PLACA ASTM A572 GR50 170X220X12MM | 1d | 2025-06-17 | 2025-06-18 | 210 | 9d |  | 931,908 |
| 214 | 17.10 | ANCLAJES CERCHA PEDESTAL (INCLUYE: 4 PERNOS DE ANCLAJE D:1/2" F1554 GR 36 LONGITUD 0.28M CON TUERCA ARRIBA Y ABAJO) | 1d | 2025-06-17 | 2025-06-18 | 210 | 1d | 0d | 2,871,808 |
| 215 | 17.11 | CERCHA METALICA EN ANGULO SEGÚN DETALLE ESTRUCTURAL (INCLUYE ANGULOS, SOLDADURA Y MANO DE OBRA) | 7d | 2025-06-18 | 2025-06-27 | 214 | 1d | 0d | 22,592,015 |
| 216 | 17.12 | PERNO ROSCADO EN "U" 1/2" TIPO 1 REFERENCIA MECANICO 363A446 O SIMILIAR PARA TUBERIA DE 3" (INCLUYE 2 ROSCAS Y MANO DE OBRA) | 1d | 2025-06-18 | 2025-06-19 | 214 | 8d |  | 359,414 |
| 217 | 17.13 | SOLDADURA ELECTROODO 1/8" E70XX | 7d | 2025-06-18 | 2025-06-27 | 214 | 2d |  | 4,343,768 |
| 218 | 17.14 | EMPALME EN TUBERIA PEAD 110MM PARA VIADUCTO LUZ 12M (INCLUYE ACCESORIOS, TUBERIA Y MANO DE OBRA) | 1d | 2025-06-28 | 2025-07-01 | 215 | 1d |  | 10,567,037 |
| 219 | 17.15 | RELLENO ROCAMUERTA COMPACT-SALTARIN | 1d | 2025-06-17 | 2025-06-18 | 210 | 2d | 0d | 1,339,690 |
| 220 | 17.16 | RETIRO DE ESCOMBROS A UNA ESCOMBRERA CERTIFICADA INCLUYE CARGUE A MANO Y ACARREO EN VOLQUETA | 7d | 2025-06-18 | 2025-06-27 | 219 | 2d |  | 3,197,237 |
| 221 | 18 | **VIADUCTO No. 2** | 24d | 2025-05-29 | 2025-07-02 |  | 0d |  | 30,023,312 |
| 222 | 18.1 | LOCALIZACION-REPLANTEO OBRA ARQUITECTON. | 1d | 2025-05-29 | 2025-05-29 | 240 | 0d |  | 1,296,680 |
| 223 | 18.2 | EXCAVACION EN CONGLOMERADO | 3d | 2025-05-30 | 2025-06-04 | 222 | 2d | 0d | 720,297 |
| 224 | 18.3 | SOLADO DE LIMPIEZA E:5CM 17,5 MPA (2500 PSI) | 2d | 2025-06-04 | 2025-06-06 | 223 | 2d |  | 110,960 |
| 225 | 18.4 | ACERO REFUERZO FLEJADO 60000 PSI 420Mpa | 7d | 2025-05-30 | 2025-06-09 | 222 | 0d |  | 2,482,591 |
| 226 | 18.5 | ZAPATA CONCRETO 3000 PSI INC. FORMALETA E:0.35M | 2d | 2025-06-10 | 2025-06-11 | 224, 225 | 0d |  | 965,197 |
| 227 | 18.6 | PEDESTAL EN CONCRETO 21 MPA (3000 PSI) 0,35X0,65 | 4d | 2025-06-12 | 2025-06-17 | 226 | 0d |  | 611,163 |
| 228 | 18.7 | MEZCLA GROUTING 1:2:3 3100 PSI -22,0 MPA | 2d | 2025-06-17 | 2025-06-19 | 227 | 8d |  | 13,014 |
| 229 | 18.8 | GROUTING DE NIVELACIÓN E:5 CM 12,5 MPA (1785 PSI) | 2d | 2025-06-17 | 2025-06-19 | 227 | 8d |  | 260,007 |
| 230 | 18.9 | PLACA ASTM A572 GR50 170X220X12MM | 1d | 2025-06-18 | 2025-06-19 | 231 | 0d |  | 465,954 |
| 231 | 18.10 | ANCLAJES CERCHA PEDESTAL (INCLUYE: 4 PERNOS DE ANCLAJE D:1/2" F1554 GR 36 LONGITUD 0.28M CON TUERCA ARRIBA Y ABAJO) | 1d | 2025-06-17 | 2025-06-18 | 227 | 0d |  | 2,942,132 |
| 232 | 18.11 | CERCHA METALICA EN ANGULO SEGÚN DETALLE ESTRUCTURAL (INCLUYE ANGULOS, SOLDADURA Y MANO DE OBRA) | 7d | 2025-06-19 | 2025-07-01 | 230 | 0d |  | 8,923,353 |
| 233 | 18.12 | PERNO ROSCADO EN "U" 1/2" TIPO 1 REFERENCIA MECANICO 363A446 O SIMILIAR PARA TUBERIA DE 3" (INCLUYE 2 ROSCAS Y MANO DE OBRA) | 1d | 2025-06-19 | 2025-06-20 | 230 | 7d |  | 179,707 |
| 234 | 18.13 | SOLDADURA ELECTROODO 1/8" E70XX | 7d | 2025-06-19 | 2025-07-01 | 230 | 1d |  | 1,134,538 |
| 235 | 18.14 | EMPALME EN TUBERIA PEAD 110MM PARA VIADUCTO LUZ 9.5M (INCLUYE ACCESORIOS, TUBERIA Y MANO DE OBRA) | 1d | 2025-07-01 | 2025-07-02 | 232 | 0d |  | 7,756,978 |
| 236 | 18.15 | RELLENO ROCAMUERTA COMPACT-SALTARIN | 1d | 2025-06-17 | 2025-06-18 | 227 | 2d | 0d | 635,884 |
| 237 | 18.16 | RETIRO DE ESCOMBROS A UNA ESCOMBRERA CERTIFICADA INCLUYE CARGUE A MANO Y ACARREO EN VOLQUETA | 7d | 2025-06-18 | 2025-06-27 | 236 | 2d |  | 1,524,857 |

| ID | WBS | Task | Duration | Start | Finish | Predecessors | Total slack | Free slack | Cost |
| --- | --- | --- | --- | --- | --- | --- | --- | --- | --- |
| 238 | 19 | **PERFORACIÓN HORIZONTAL DIRIGIDA DE TUBERÍA** | 13d | 2025-05-13 | 2025-05-28 |  | 0d |  | 36,768,943 |
| 239 | 19.1 | EXCAVACION EN CONGLOMERADO | 10d | 2025-05-13 | 2025-05-24 | 203 | 0d |  | 4,244,984 |
| 240 | 19.2 | PERFORACIÓN TELEDIRIGIDA PARA TUBERIA PEAD 110MM (INCLUYE TRANSPORTE DE EQUIPO, MATERIALES, EQUIPO DE TERMOFUSIÓN, ADECUACION DEL PUNTO Y EQUIPO DE TOPOGRAFIA) | 3d | 2025-05-26 | 2025-05-28 | 239 | 0d |  | 28,093,061 |
| 241 | 19.3 | PERFORACIÓN TELEDIRIGIDA PARA TUBERIA PEAD 225MM (INCLUYE TRANSPORTE DE EQUIPO, MATERIALES, EQUIPO DE TERMOFUSIÓN, ADECUACION DEL PUNTO Y EQUIPO DE TOPOGRAFIA) | 1d | 2025-05-26 | 2025-05-26 | 239 | 26d |  | 4,430,898 |
| 242 | 20 | **INSTALACIONES ELECTRICAS ESTACION DE BOMBEO AGUA RESIDUAL** | 30d? | 2025-03-14 | 2025-04-25 |  | 49d |  | 194,588,354 |
| 243 | 20.1 | **ADECUACION PUNTO CONEXIÓN RED PRIMARIA TRIFASICA 13,2 KV Y MONTAJE SUBESTACION EXTERIOR EN POSTE CON TRANSFORMADOR DE 45KVA CONVENCIONAL 3F 13200/230-127V** | 7d | 2025-03-14 | 2025-03-25 |  | 70d |  | 23,798,043 |
| 245 | 20.1.1 | APERTURA HUECOS POSTES ANCLAS PRIMARIAS | 1d | 2025-03-14 | 2025-03-15 | 103 | 78d |  | 64,731 |
| 246 | 20.1.2 | POSTE CONCRETO 12 X 510 KG | 1d | 2025-03-17 | 2025-03-17 | 247 | 70d | 0d | 2,673,549 |
| 247 | 20.1.3 | TRANSP.POSTE.CONC.12MT.SITIO SIN INCREME | 1d | 2025-03-14 | 2025-03-15 | 103 | 70d | 0d | 235,000 |
| 248 | 20.1.4 | APLOMADA POSTES DE CONCRETO PRIMARIOS | 1d | 2025-03-18 | 2025-03-18 | 246 | 70d | 0d | 75,032 |
| 249 | 20.1.5 | CONCRETADA DE POSTES PRIMARIOS | 1d | 2025-03-19 | 2025-03-19 | 248 | 70d | 0d | 104,103 |
| 250 | 20.1.6 | B51L CORRIDO TRIFASICO ANG 0- 3 | 1d | 2025-03-20 | 2025-03-20 | 249 | 72d | 0d | 1,047,659 |
| 251 | 20.1.7 | FB-31 CORTACIRCUITOS SISTEMA TRIFASICO | 1d | 2025-03-22 | 2025-03-25 | 254 | 72d |  | 1,282,922 |
| 252 | 20.1.8 | PB-31 PARARRAYOS SISTEMA TRIFASICO | 1d | 2025-03-22 | 2025-03-25 | 254 | 72d |  | 1,253,238 |
| 253 | 20.1.9 | T1 CON D.I. TIERRA CON DUCTO INTERNO | 1d | 2025-03-22 | 2025-03-25 | 254 | 72d |  | 621,588 |
| 254 | 20.1.10 | TRANSFORMADOR TRIFASICO 45 KVA 13200 V. | 1d | 2025-03-21 | 2025-03-21 | 250 | 72d | 0d | 16,440,221 |
| 255 | 20.2 | **EQUIPO MEDICION INDIRECTA NIVEL 2 MEDIA TENSION 13200V/ EN POSTE CONCRETO 12 X 510 KGS MONTAJE EN ESTRUCTURA CENTRO** | 5d | 2025-03-20 | 2025-03-27 |  | 70d |  | 25,865,375 |
| 256 | 20.2.1 | CAJA METALICA PARA CONTADOR TIPO A, EXTERIOR DE 70 X 50 X 30 CON DOS ESPACIOS PARA CONTADOR ELECTRONICO Y BLOQUE DE PRUEBAS TIPO CUCHILLA | 1d | 2025-03-20 | 2025-03-20 | 249 | 73d | 0d | 1,477,018 |
| 257 | 20.2.2 | CONTADOR ELECTRONICO M.INDIRECTA | 1d | 2025-03-21 | 2025-03-21 | 258 | 73d |  | 5,402,235 |
| 258 | 20.2.3 | CABLE DE CONTROL 7X12 | 1d | 2025-03-20 | 2025-03-20 | 249 | 70d | 0d | 642,860 |
| 259 | 20.2.4 | TRAFO POTENCIAL MT MEDIDA EXTERIOR TPS 13200/120 V 3F CLASE 0,5 15 KV | 2d | 2025-03-21 | 2025-03-25 | 258 | 72d |  | 7,841,208 |
| 260 | 20.2.5 | TRAFO CORRIENTE MT DE MEDIDA EXTERIOR TCS 3/5 A CLASE 0,5 15 KV | 2d | 2025-03-21 | 2025-03-25 | 258 | 72d |  | 7,284,368 |
| 261 | 20.2.6 | ESTRUCTURA CENTRO SOPORTE EQUIPOS MEDICION TPS Y TCS | 2d | 2025-03-21 | 2025-03-25 | 258 | 70d | 0d | 1,550,854 |
| 262 | 20.2.7 | ABRAZADERA GALVANIZADA DE 10" | 1d | 2025-03-26 | 2025-03-27 | 265 | 70d |  | 92,868 |
| 263 | 20.2.8 | ATERRIZAJE CAJA METALICA, TABLERO , CONTADOR | 1d | 2025-03-21 | 2025-03-21 | 256 | 73d |  | 578,684 |
| 264 | 20.2.9 | ALAMBRE CU DD # 4 AWG | 1d | 2025-03-21 | 2025-03-21 | 256 | 73d |  | 757,696 |
| 265 | 20.2.10 | TUBO GALV 1 X 3MTS | 1d | 2025-03-25 | 2025-03-26 | 261 | 70d | 0d | 237,584 |

| ID | WBS | Task | Duration | Start | Finish | Predecessors | Total slack | Free slack | Cost |
| --- | --- | --- | --- | --- | --- | --- | --- | --- | --- |
| 266 | 20.3 | **ACOMETIDA Y/O ALIMENTADOR SOBRE POSTE Y SUBTERRANEO BT TRIFASICO 220 V DESDE BORNES SECUNDARIOS DEL TRAFO, PASANDO POR TABLERO DE TRANSFERENCIA (TTF) HASTA TABLERO (TP)** | 4d | 2025-03-14 | 2025-03-19 |  | 55d |  | 9,516,601 |
| 267 | 20.3.1 | CABLE COBRE HF-ZH# 1/0 | 2d | 2025-03-17 | 2025-03-18 | 268 | 55d | 0d | 7,136,780 |
| 268 | 20.3.2 | TUBO GALV 2 X3 MTS | 1d | 2025-03-14 | 2025-03-15 | 103 | 55d | 0d | 760,521 |
| 269 | 20.3.3 | TUBO PVC 2 | 1d | 2025-03-14 | 2025-03-15 | 103 | 78d |  | 1,126,550 |
| 270 | 20.3.4 | TABLERO 3F 18 CTOS NTQ | 1d | 2025-03-19 | 2025-03-19 | 267 | 55d | 0d | 492,750 |
| 271 | 20.4 | **OBRAS CIVILES COMPLEMENTARIAS PARA LA OBRA ELECTRICA** | 5d | 2025-03-19 | 2025-03-26 |  | 71d |  | 5,049,232 |
| 272 | 20.4.1 | CAJA ELECTRICA 0,3 X 0,3 X 0,5 MT | 1d | 2025-03-25 | 2025-03-26 | 275 | 71d |  | 1,380,684 |
| 273 | 20.4.2 | CAJA ELECTRICA DE 0,5 X 0,5 X 0,8 M | 1d | 2025-03-25 | 2025-03-26 | 275 | 71d |  | 814,168 |
| 274 | 20.4.3 | EXCAVACION TIERRA A MANO | 3d | 2025-03-19 | 2025-03-21 | 267 | 71d | 0d | 640,020 |
| 275 | 20.4.4 | BASE CONCRETO 50 X 50 X 50 CM PARA SOPORTE TUBO GALV. 3 " PARA LUMINARIA DE 6 M | 1d | 2025-03-22 | 2025-03-25 | 274 | 71d | 0d | 2,214,360 |
| 276 | 20.5 | **ALIMENTADOR DE B.T TRIFASICO A 220V SUBTERRANEO DE TABLERO (TP) HASTA TABLERO (TB) DE ARRANQUE, CONTROL Y MANDO PARA DOS BOMBAS** | 2d | 2025-03-14 | 2025-03-17 |  | 77d |  | 3,436,470 |
| 277 | 20.5.1 | CABLE COBRE HF-ZH# 4 | 1d | 2025-03-17 | 2025-03-17 | 278 | 77d |  | 2,561,100 |
| 278 | 20.5.2 | TUBO PVC 2 | 1d | 2025-03-14 | 2025-03-15 | 103 | 77d | 0d | 675,930 |
| 279 | 20.5.3 | CABLE COBRE HF-ZH# 8 | 1d | 2025-03-17 | 2025-03-17 | 278 | 77d |  | 199,440 |
| 280 | 20.6 | **ALIMENTADOR DE B.T TRIFASICO SUBTERRANEO DE TABLERO TP HASTA PUNTO CONEXIÓN POLIPASTO # 1 Y # 2** | 2d | 2025-03-14 | 2025-03-17 |  | 77d |  | 2,201,570 |
| 281 | 20.6.1 | CABLE COBRE HF-ZH# 10 | 1d | 2025-03-17 | 2025-03-17 | 283 | 77d |  | 908,600 |
| 282 | 20.6.2 | CABLE COBRE HF-ZH# 10 | 1d | 2025-03-17 | 2025-03-17 | 283 | 77d |  | 227,150 |
| 283 | 20.6.3 | TUBO PVC 1 | 1d | 2025-03-14 | 2025-03-15 | 103 | 77d | 0d | 1,065,820 |
| 284 | 20.7 | **MALLA PUESTA TIERRA TRIANGULAR TERMOFUNDIDA LADO ZONA VERDE INTERIOR DEL PERIMETRO DE LA EVAR** | 19d | 2025-03-14 | 2025-04-09 |  | 60d |  | 3,141,096 |
| 285 | 20.7.1 | CABLE COBRE DESNUDO #2 | 1d | 2025-04-08 | 2025-04-09 | 185 | 60d |  | 920,910 |
| 286 | 20.7.2 | VARILLA CU-CU 9/16X 2.40 | 1d | 2025-03-14 | 2025-03-15 | 103 | 73d | 0d | 1,309,353 |
| 287 | 20.7.3 | SOLDADURA TERMOWELD X115 GRM | 1d | 2025-03-17 | 2025-03-17 | 286 | 73d | 0d | 321,774 |
| 288 | 20.7.4 | TAPA METALICA DE REGISTRO 20X20 | 1d | 2025-03-18 | 2025-03-18 | 287 | 76d |  | 341,079 |
| 289 | 20.7.5 | SACO HIDROSOLTA DE 5 KG | 1d | 2025-03-18 | 2025-03-18 | 287 | 73d | 0d | 247,980 |

| ID | WBS | Task | Duration | Start | Finish | Predecessors | Total slack | Free slack | Cost |
| --- | --- | --- | --- | --- | --- | --- | --- | --- | --- |
| 290 | 20.8 | **CIRCUITOS RAMALES, CONTROL Y SALIDAS ELECTRICAS DE FUERZA, ILUMINACION INTERIOR Y EXTERIOR DEL TABLERO (TP) CUARTO ELECTRICO** | 3d? | 2025-03-19 | 2025-03-21 |  | 73d |  | 29,197,763 |
| 291 | 20.8.1 | SAL LAMP PVC | 1d | 2025-03-20 | 2025-03-20 | 298 | 73d | 0d | 1,128,344 |
| 292 | 20.8.2 | BALA PANEL LED 24W | 1d | 2025-03-21 | 2025-03-21 | 291 | 73d |  | 432,016 |
| 293 | 20.8.3 | SALIDA S1 PVC | 1d | 2025-03-20 | 2025-03-20 | 298 | 74d |  | 177,030 |
| 294 | 20.8.4 | SALIDA S2 PVC | 1d | 2025-03-20 | 2025-03-20 | 298 | 74d |  | 562,644 |
| 295 | 20.8.5 | SALIDA S3 PVC | 1d | 2025-03-20 | 2025-03-20 | 298 | 74d |  |  |
| 296 | 20.8.6 | SAL TOMA 120 PVC | 1d | 2025-03-20 | 2025-03-20 | 298 | 74d |  | 589,116 |
| 297 | 20.8.7 | SAL TOMA 220 PVC | 1d | 2025-03-20 | 2025-03-20 | 298 | 74d |  | 276,098 |
| 298 | 20.8.8 | ACOM 2F (2F # 12 + 1N #12 + 1T #12) 3/4 "PVC | 1d | 2025-03-19 | 2025-03-19 | 289 | 73d | 0d | 866,720 |
| 299 | 20.8.9 | ACOM.E.2F(2# 12+1#12) ,3/4" EMT" | 1d | 2025-03-19 | 2025-03-19 | 289 | 73d | 0d | 850,900 |
| 300 | 20.8.10 | LUMINARIA 80 LED COMPLETA | 1d | 2025-03-21 | 2025-03-21 | 301 | 73d |  | 19,773,475 |
| 301 | 20.8.11 | POSTE TUBO GALV. 3" X3.6MM C.XX ACUE" | 1d | 2025-03-20 | 2025-03-20 | 299 | 73d | 0d | 3,323,340 |
| 302 | 20.8.12 | TUBO PVC CONDUIT 1" | 1d? | 2025-03-21 | 2025-03-21 | 301 | 73d |  | 1,218,080 |
| 303 | 20.9 | **PROTECCIONES PRINCIPALES ALIMENTADORES Y CIRCUITOS ELECTRICOS DE FUERZA E ILUMINACION INTERIOR Y EXTERIOR DE LOS TABLEROS TP PRINCIPAL Y ESPACIO DE LAPROTECCION PRINCIPAL EN LA CAJA DE MEDICION INDIRECA EN POSTE** | 1d | 2025-03-20 | 2025-03-20 |  | 55d |  | 3,469,749 |
| 304 | 20.9.1 | BREAKER 3F DESDE 100 HASTA 150 AMP | 1d | 2025-03-20 | 2025-03-20 | 270 | 55d | 0d | 1,069,830 |
| 305 | 20.9.2 | BREAKER 3F DESDE 60 HASTA 100 AMP | 1d | 2025-03-20 | 2025-03-20 | 270 | 74d |  | 966,442 |
| 306 | 20.9.3 | BREAKER 3F DESDE 15 HASTA 50 AMP | 1d | 2025-03-20 | 2025-03-20 | 270 | 74d |  | 481,280 |
| 307 | 20.9.4 | BREAKER 1F DESDE 15 HASTA 60 AMP | 1d | 2025-03-20 | 2025-03-20 | 270 | 74d |  | 379,850 |
| 308 | 20.9.5 | BREAKER 2F DESDE 15 HASTA 60 AMP | 1d | 2025-03-20 | 2025-03-20 | 270 | 74d |  | 138,785 |
| 309 | 20.9.6 | ATERRIZAJE CAJA METALICA, TABLERO , CONTADOR | 1d | 2025-03-20 | 2025-03-20 | 270 | 74d |  | 433,562 |
| 310 | 20.10 | **SERVICIO DE ENERGIA ELECTRICA PARA USO EN PLANTA DE EMERGENCIA** | 4d | 2025-03-21 | 2025-03-27 |  | 55d |  | 67,677,631 |
| 311 | 20.10.1 | PLANTA ELECTRICA DIESEL 32 KVA 25 KW TRIFASICA 220-110V CON TRANSFERENCIA AUTOMATICA ELECTRONICA | 4d | 2025-03-21 | 2025-03-27 | 304 | 55d | 0d | 67,677,631 |
| 312 | 20.11 | **TRAMITES PROYECTO ELECTRICO, PAGOS Y SERVICIOS AL OPERADOR DE RED CELSIA Y OTROS** | 30d | 2025-03-14 | 2025-04-25 |  | 49d |  | 21,234,824 |
| 313 | 20.11.1 | CERTIFICACION RETIE | 15d | 2025-03-27 | 2025-04-15 | 311 | 55d |  | 6,623,824 |
| 314 | 20.11.2 | TRAMITES Y PAGO DE APROBACION PROYECTO ELECTRICO CELSIA | 30d | 2025-03-14 | 2025-04-25 | 103 | 49d |  | 4,350,000 |
| 315 | 20.11.3 | PAGO DERECHO INTERVENTORIA Y APROBACION DE OBRA CON PUNTO DE CONEXION CELSIA | 30d | 2025-03-14 | 2025-04-25 | 103 | 49d |  | 2,785,000 |
| 316 | 20.11.4 | TRABAJO CONEXION PUENTES PRIMARIOS Y CAMBIO DE POSTE DE CONCRETO CUADRILLA LINEA VIVA CELSIA, INSTALACION EQUIPO MEDIDA NIVEL 2 | 30d | 2025-03-14 | 2025-04-25 | 103 | 49d |  | 7,476,000 |
